# May 2005 ALS Startup

Schedule from MS Project, 2005-04-10 to 2005-05-18, status date 2004-04-14, 24 hours a day.
Schedule for 2005 Startup
LBNL

## Calendars

- 24 Hours: Mon-Sun 00:00-24:00.

## Resources

| Resource |
| --- |
| Byrd |
| Barry |
| Stover |
| Steier |
| Scarvie |
| Biocca |
| Chin |
| Webber |
| Timossi |
| Jacobson |
| Domning |
| Calais |
| Bish |
| Zbasnik |
| Thur |
| Kwiatkowski |
| Marks |
| Robb |
| Harkins |
| Byrne |
| Operators |
| Colomb |
| Fairchild |
| Physics |
| Robin |
| Nishimura |
| deSantis |
| Duarte |
| Gavidia |
| Hamamoto |
| Beamlines |
| Cork |
| Julian |
| Baptiste |
| Plate |
| Williams |
| Fahmie |
| Steie |
| EM |
| Wan |
| Wolski |
| Kwiatkowsk |
| Wittmer |
| Portmann |

## Schedule

| ID | WBS | Task | Type | Duration | Start | Finish | Predecessors | Baseline start | Baseline finish | Baseline duration | Total slack | Free slack | Constraint | Resources | Work |
| --- | --- | --- | --- | --- | --- | --- | --- | --- | --- | --- | --- | --- | --- | --- | --- |
| 1 | 1 | Baseline Measurements done (Power Supplies, Orbit, Injection, Coupling, …) | milestone | 0d | 2005-04-10 08:00 | 2005-04-10 08:00 |  |  |  |  | 38d |  | start no earlier than 2005-04-10 08:00 | Steier; Scarvie |  |
| 2 | 2 | Baseline Measurements done (LFB, TFB, growth rates, mode spectrum beam, mode spectrum harmonic cavities, ...) | milestone | 0d | 2005-04-10 08:00 | 2005-04-10 08:00 |  |  |  |  | 38d |  | start no earlier than 2005-04-10 08:00 | Byrd; Barry; Stover; Kwiatkowski |  |
| 3 | 3 | Shutdown Start | milestone | 0d | 2005-04-11 08:00 | 2005-04-11 08:00 |  |  |  |  | 16.22d | 0d | start no earlier than 2005-04-11 08:00 |  |  |
| 5 | 4 | **Work during Shutdown** |  | 25d | 2005-04-11 08:00 | 2005-05-06 08:00 | 3 |  |  |  | 2.06d | 0d |  |  | 1040h |
| 6 | 4.1 | Potentially Matlab HL software work |  | 2.5ed | 2005-04-11 08:00 | 2005-04-13 20:00 |  |  |  |  | 27.72d |  | start no earlier than 2004-04-26 08:00 | Scarvie; Steier | 32h |
| 7 | 4.2 | Check out thermal behaviour of Superbends |  | 7ed | 2005-04-20 08:00 | 2005-04-27 08:00 |  |  |  |  | 7.22d | 0d | start no earlier than 2005-04-20 08:00 | Calais; Steier; Fahmie | 504h |
| 8 | 4.3 | Check out Superbend ramping with new coldheads |  | 7ed | 2005-04-27 08:00 | 2005-05-04 08:00 | 7 |  |  |  | 7.22d | 0d | start no earlier than 2003-03-31 08:00 | Calais; Steier; Fahmie | 504h |
| 9 | 4.4 | Superbends ready for startup | milestone | 0d | 2005-05-04 08:00 | 2005-05-04 08:00 | 7, 8 |  |  |  | 7.22d |  | start no earlier than 2003-04-20 08:00 | Calais |  |
| 10 | 4.5 | 2nd main RF HOM dampers installed | milestone | 0d | 2005-05-02 08:00 | 2005-05-02 08:00 |  |  |  |  | 8.22d | 0d | start no earlier than 2005-05-02 08:00 | Kwiatkowski |  |
| 11 | 4.6 | Control System 100% Functional | milestone | 0d | 2005-05-06 08:00 | 2005-05-06 08:00 |  | 2001-08-30 08:00 | 2001-08-30 08:00 | 0d | 2.06d | 1.33d | start no earlier than 2005-05-06 08:00 | Biocca; Steier |  |
| 13 | 5 | **Finish Shutdown, start Injector** |  | 2.67d | 2005-05-06 08:00 | 2005-05-09 00:00 | 5 |  |  |  | 2.06d |  |  |  | 60h |
| 14 | 5.1 | Finish all shutdown work | milestone | 0d | 2005-05-06 08:00 | 2005-05-06 08:00 | 5 | 2001-08-30 08:00 | 2001-08-30 08:00 | 0d | 2.06d | 0d | start no earlier than 2005-05-06 08:00 | Harkins |  |
| 15 | 5.2 | Search and secure LINAC, booster + SR |  | 2eh | 2005-05-06 08:00 | 2005-05-06 10:00 | 14 | 2001-08-30 08:00 | 2001-08-30 08:00 | 0d | 2.06d | 0.92d | start no earlier than 2003-03-31 08:00 | Operators [200%] | 4h |
| 16 | 5.3 | Follow comprehensive startup procedure (Linac+booster) |  | 8eh | 2005-05-07 08:00 | 2005-05-07 16:00 | 14, 15 | 2001-08-30 08:00 | 2001-08-30 08:00 | 0d | 1.14d | 0d | start no earlier than 2005-05-07 08:00 | Operators [200%] | 16h |
| 17 | 5.4 | Follow comprehensive startup procedure (Storage Ring) |  | 16eh | 2005-05-08 08:00 | 2005-05-09 00:00 | 14, 16 | 2001-08-30 08:00 | 2001-08-30 08:00 | 0d | 0.47d | 0.33d | start no earlier than 2005-05-08 08:00 | Operators [200%] | 32h |
| 18 | 5.5 | Setup Beam Thru Injector and BTS Line |  | 8eh | 2005-05-07 16:00 | 2005-05-08 00:00 | 15, 11, 16 | 2001-08-30 08:00 | 2001-09-04 17:00 | 1.33d | 1.64d | 1.5d | start no earlier than 2003-04-21 08:00 | Byrne | 8h |
| 19 | 5.6 | Switch on all hardware in storage ring - Do NOT INJECT |  | 8eh | 2005-05-08 08:00 | 2005-05-08 16:00 |  |  |  |  | 9.67d |  | start no earlier than 2005-05-08 08:00 |  |  |
| 21 | 6 | Good Vacuum W/O Beam (Sublimate early enough) | milestone | 0d | 2005-05-08 08:00 | 2005-05-08 08:00 | 14 | 2001-08-30 08:00 | 2001-08-30 08:00 | 0d | 10d |  | start no earlier than 2005-05-08 08:00 | Colomb; Operators |  |
| 23 | 7 | **Hardware Checkout W/O Beam** |  | 0.17d | 2005-05-09 08:00 | 2005-05-09 12:00 | 15, 17, 11, 5 | 2001-09-04 08:00 | 2001-09-04 16:00 | 0.33d | 0.14d | 0d | start no earlier than 2004-05-31 08:00 |  | 8.35h |
| 24 | 7.1 | DCCT |  | 0.2eh | 2005-05-09 08:00 | 2005-05-09 08:12 |  | 2001-09-04 08:00 | 2001-09-04 08:30 | 0.5h | 0.18d | 0d | start no earlier than 2005-05-09 08:00 | Physics | 0.2h |
| 25 | 7.2 | Scrapers |  | 1eh | 2005-05-09 08:12 | 2005-05-09 09:12 | 24 | 2001-09-04 08:30 | 2001-09-04 09:30 | 1h | 0.18d | 0d | start no earlier than 2003-03-31 08:00 | Physics | 1h |
| 26 | 7.3 | Tune Measurement System |  | 0.2eh | 2005-05-09 09:12 | 2005-05-09 09:24 | 25 | 2001-09-04 09:30 | 2001-09-04 10:30 | 1h | 0.18d | 0d | start no earlier than 2003-03-31 08:00 | Physics | 0.2h |
| 27 | 7.4 | RF Frequency |  | 0.2eh | 2005-05-09 09:24 | 2005-05-09 09:36 | 26 | 2001-09-04 10:30 | 2001-09-04 11:00 | 0.5h | 0.18d | 0d | start no earlier than 2003-03-31 08:00 | Physics | 0.2h |
| 28 | 7.5 | BPM and IDBPM data rates (no beam) |  | 0.5eh | 2005-05-09 09:36 | 2005-05-09 10:06 | 27 | 2001-09-04 11:00 | 2001-09-04 13:00 | 2h | 0.18d | 0d | start no earlier than 2003-03-31 08:00 | Physics [50%] | 0.25h |
| 29 | 7.6 | Shunts |  | 1eh | 2005-05-09 10:06 | 2005-05-09 11:06 | 28 | 2001-09-04 11:00 | 2001-09-04 13:00 | 2h | 0.18d |  | start no earlier than 2003-03-31 08:00 | Physics [50%] | 0.5h |

| ID | WBS | Task | Type | Duration | Start | Finish | Predecessors | Baseline start | Baseline finish | Baseline duration | Total slack | Free slack | Constraint | Resources | Work |
| --- | --- | --- | --- | --- | --- | --- | --- | --- | --- | --- | --- | --- | --- | --- | --- |
| 30 | 7.7 | **Test all Power Supplies (especially modified skew quadrupoles)** |  | 0.17d | 2005-05-09 08:00 | 2005-05-09 12:00 |  | 2001-09-04 08:00 | 2001-09-04 16:00 | 0.33d | 0.14d |  |  |  | 6h |
| 31 | 7.7.1 | Stability |  | 2eh | 2005-05-09 08:00 | 2005-05-09 10:00 |  | 2001-09-04 08:00 | 2001-09-04 12:00 | 4h | 0.22d |  | start no earlier than 2005-05-09 08:00 | Physics [50%] | 1h |
| 32 | 7.7.2 | SP-AM |  | 2eh | 2005-05-09 08:00 | 2005-05-09 10:00 |  | 2001-09-04 08:00 | 2001-09-04 12:00 | 4h | 0.22d |  | start no earlier than 2005-05-09 08:00 | Physics [50%] | 1h |
| 33 | 7.7.3 | Data Rates |  | 2eh | 2005-05-09 08:00 | 2005-05-09 10:00 |  | 2001-09-04 08:00 | 2001-09-04 12:00 | 4h | 0.14d | 0d | start no earlier than 2005-05-09 08:00 | Physics [50%] | 1h |
| 34 | 7.7.4 | Ramping |  | 2eh | 2005-05-09 10:00 | 2005-05-09 12:00 | 33 | 2001-09-04 12:00 | 2001-09-04 16:00 | 4h | 0.14d |  | start no earlier than 2005-05-09 08:00 | Physics | 2h |
| 35 | 7.7.5 | Check Power Supply Can Reach Max/Min Current |  | 1eh | 2005-05-09 10:00 | 2005-05-09 11:00 | 33 | 2001-09-04 12:00 | 2001-09-04 16:00 | 4h | 0.18d |  | start no earlier than 2003-03-31 08:00 | Physics | 1h |
| 37 | 8 | **Start storage ring injection (watch HOM damper temperatures)** |  | 0.32d | 2005-05-09 12:00 | 2005-05-09 19:39 | 23, 18 | 2001-09-04 16:30 | 2001-09-05 20:30 | 0.81d | 0.14d | 0d |  |  | 27.3h |
| 38 | 8.1 | First fill single bunch and verify/optimize THC tuning with HOM dampers |  | 2eh | 2005-05-09 12:00 | 2005-05-09 14:00 |  |  |  |  | 2.21d | 0d |  | Kwiatkowski; Byrd | 4h |
| 39 | 8.2 | Radiation survey during injection and stored beam (desired to go to multibunch 200 mA) |  | 2eh | 2005-05-09 14:00 | 2005-05-09 16:00 | 38 | 2001-09-04 16:30 | 2001-09-04 20:30 | 4h | 2.21d |  | start no earlier than 2003-03-31 08:00 | Fairchild | 2h |
| 40 | 8.3 | Watch temperatures of HOM dampers -> do not overfill ring |  | 2eh | 2005-05-09 12:00 | 2005-05-09 14:00 |  | 2001-09-04 16:30 | 2001-09-04 20:30 | 4h | 2.29d |  | start no earlier than 2003-03-31 08:00 | Kwiatkowski; Julian; Baptiste; Physics; Operators | 10h |
| 41 | 8.4 | Correct first turn orbit |  | 1eh | 2005-05-09 12:00 | 2005-05-09 13:00 |  | 2001-09-04 16:30 | 2001-09-04 20:30 | 4h | 0.14d | 0d | start no earlier than 2003-03-31 08:00 | Steier; Scarvie | 2h |
| 42 | 8.5 | Adjust tunes/lattice |  | 1eh | 2005-05-09 13:00 | 2005-05-09 14:00 | 41 | 2001-09-05 08:00 | 2001-09-05 10:00 | 2h | 0.14d | 0d | start no earlier than 2003-03-31 08:00 | Steier; Scarvie | 2h |
| 43 | 8.6 | Tune rf phase - relative energy |  | 0.5eh | 2005-05-09 14:00 | 2005-05-09 14:30 | 42 | 2001-09-05 10:00 | 2001-09-05 12:00 | 2h | 0.14d | 0d | start no earlier than 2003-03-31 08:00 | Steier; Byrne | 1h |
| 44 | 8.7 | **Initial multi turn optimization/store beam** |  | 0.21d | 2005-05-09 14:30 | 2005-05-09 19:39 | 43 | 2001-09-05 12:00 | 2001-09-05 20:30 | 8h | 0.14d | 0d |  |  | 6.3h |
| 45 | 8.7.1 | **BPM checkout** |  | 0.03d | 2005-05-09 14:30 | 2005-05-09 15:06 |  | 2001-09-07 08:00 | 2001-09-07 09:30 | 0.06d | 0.14d |  |  |  | 1.2h |
| 46 | 8.7.1.1 | Check BPMs Calibrate |  | 0.2eh | 2005-05-09 14:30 | 2005-05-09 14:42 |  | 2001-09-07 08:00 | 2001-09-07 08:30 | 0.5h | 0.14d | 0d | start no earlier than 2003-03-31 08:00 | Steier; Scarvie | 0.4h |
| 47 | 8.7.1.2 | Check Sample Rates |  | 0.2eh | 2005-05-09 14:42 | 2005-05-09 14:54 | 46 | 2001-09-07 08:30 | 2001-09-07 09:00 | 0.5h | 0.14d | 0d | start no earlier than 2003-03-31 08:00 | Steier; Scarvie | 0.4h |
| 48 | 8.7.1.3 | Measure Noise |  | 0.2eh | 2005-05-09 14:54 | 2005-05-09 15:06 | 47 | 2001-09-07 09:00 | 2001-09-07 09:30 | 0.5h | 0.14d | 0d | start no earlier than 2003-03-31 08:00 | Steier; Scarvie | 0.4h |
| 49 | 8.7.2 | Tune Measurement |  | 0.2eh | 2005-05-09 15:06 | 2005-05-09 15:18 | 48 | 2001-09-07 09:30 | 2001-09-07 10:00 | 0.5h | 0.14d | 0d | start no earlier than 2003-03-31 08:00 | Steier; Scarvie | 0.4h |
| 50 | 8.7.3 | RF Frequency |  | 0.1eh | 2005-05-09 15:18 | 2005-05-09 15:24 | 49 | 2001-09-07 10:00 | 2001-09-07 10:30 | 0.5h | 0.14d | 0d | start no earlier than 2003-03-31 08:00 | Steier; Scarvie | 0.2h |
| 51 | 8.7.4 | Quick setup (orbit, tune, chrom correction) |  | 1eh | 2005-05-09 15:24 | 2005-05-09 16:24 | 50 | 2001-09-07 10:00 | 2001-09-07 10:30 | 0.5h | 0.14d | 0d | start no earlier than 2003-03-31 08:00 | Steier; Scarvie | 2h |
| 52 | 8.7.5 | Skew quadrupole response matrix (dispersion) |  | 2eh | 2005-05-09 16:24 | 2005-05-09 18:24 | 51 |  |  |  | 0.14d | 0d |  |  |  |
| 53 | 8.7.6 | Response Matrix Measured |  | 0.75eh | 2005-05-09 18:24 | 2005-05-09 19:09 | 50, 52 | 2001-09-07 10:30 | 2001-09-07 11:00 | 0.5h | 0.14d | 0d | start no earlier than 2003-03-31 08:00 | Steier; Scarvie | 1.5h |
| 54 | 8.7.7 | Measurement Of Orbit Jitter |  | 0.5eh | 2005-05-09 19:09 | 2005-05-09 19:39 | 53 | 2001-09-06 10:30 | 2001-09-06 11:00 | 0.5h | 0.14d |  | start no earlier than 2003-03-31 08:00 | Steier; Scarvie | 1h |
| 56 | 9 | First Stored Beam in SR | milestone | 0d | 2005-05-09 19:39 | 2005-05-09 19:39 | 44 | 2001-09-06 08:00 | 2001-09-06 08:00 | 0d | 0.56d | 0.42d | start no earlier than 2003-03-31 08:00 | Steier |  |

| ID | WBS | Task | Type | Duration | Start | Finish | Predecessors | Baseline start | Baseline finish | Baseline duration | Total slack | Free slack | Constraint | Resources | Work |
| --- | --- | --- | --- | --- | --- | --- | --- | --- | --- | --- | --- | --- | --- | --- | --- |
| 58 | 10 | **Beam Physics Studies (HOM dampers, instabilities, feedbacks, beam based alignment, orbit, …)** |  | 3.46d | 2005-05-09 19:39 | 2005-05-13 06:39 | 37 | 2001-09-07 14:00 | 2001-09-08 05:00 | 0.4d | 0.14d | 0d |  |  | 177.85h |
| 59 | 10.1 | Test of HOM dampers 1 (different fill patterns, currents and cavity temperatures) |  | 10eh | 2005-05-09 19:39 | 2005-05-10 05:39 |  |  |  |  | 0.14d | 0d | start no earlier than 2003-03-31 08:00 | Kwiatkowski; Byrd; Barry; Stover | 40h |
| 60 | 10.2 | Scrub With Beam (1.9 GeV) -> maybe more time needed ? Vacuumwork in sectors 2,3,4,6,… ! |  | 6eh | 2005-05-10 05:39 | 2005-05-10 11:39 | 56, 59 | 2001-09-06 09:30 | 2001-09-06 18:00 | 8h | 0.14d | 0d | start no earlier than 2003-03-31 08:00 | Operators | 6h |
| 61 | 10.3 | During Scrubbing: Test Slow Orbit Feedback and new ML software (later in week potentially give some beam to users - BL 5?) |  | 6eh | 2005-05-10 11:39 | 2005-05-10 17:39 | 56, 60 | 2001-09-07 11:30 | 2001-09-07 12:00 | 0.5h | 0.14d | 0d | start no earlier than 2003-03-31 08:00 | Steier; Scarvie | 12h |
| 62 | 10.4 | Analyze response matrix |  | 2eh | 2005-05-10 17:39 | 2005-05-10 19:39 | 53, 61 | 2001-09-06 09:30 | 2001-09-06 18:00 | 8h | 0.14d | 0d | start no earlier than 2003-03-31 08:00 | Steier [10%] | 0.2h |
| 63 | 10.5 | Sufficiently Good Vacuum For Precision Machine Studies | milestone | 0d | 2005-05-10 19:39 | 2005-05-10 19:39 | 60, 62 | 2001-09-06 18:00 | 2001-09-06 18:00 | 0d | 0.14d | 0d | start no earlier than 2003-03-31 08:00 |  |  |
| 64 | 10.6 | EPBI Test 2 |  | 6eh | 2005-05-10 19:39 | 2005-05-11 01:39 | 63 | 2001-09-09 15:30 | 2001-09-09 23:00 | 7h | 0.14d | 0d | start no earlier than 2003-03-31 08:00 | Byrne; Operators | 12h |
| 65 | 10.7 | Measure absolute orbits/coupling |  | 4eh | 2005-05-11 01:39 | 2005-05-11 05:39 | 64 |  |  |  | 0.14d | 0d | start no earlier than 2003-03-31 08:00 | Nishimura | 4h |
| 66 | 10.8 | Prepare For/Test Beam Based Alignment |  | 2eh | 2005-05-11 05:39 | 2005-05-11 07:39 | 65 | 2001-09-10 16:30 | 2001-09-10 19:30 | 3h | 0.14d | 0d | start no earlier than 2003-03-31 08:00 | Scarvie | 2h |
| 67 | 10.9 | **Beam Based Alignment** |  | 0.62d | 2005-05-11 07:39 | 2005-05-11 22:39 | 66 | 2001-09-10 16:30 | 2001-09-10 19:30 | 3h | 0.14d | 0d |  |  | 30h |
| 68 | 10.9.1 | Find QF and QD Centers |  | 6eh | 2005-05-11 07:39 | 2005-05-11 13:39 |  | 2001-09-11 08:00 | 2001-09-12 09:30 | 16h | 0.14d | 0d |  | Physics; Operators | 12h |
| 69 | 10.9.2 | Find QFA+QDA Centers |  | 6eh | 2005-05-11 13:39 | 2005-05-11 19:39 | 68 | 2001-09-12 09:30 | 2001-09-12 18:00 | 8h | 0.14d | 0d | start no earlier than 2003-03-31 08:00 | Physics; Operators | 12h |
| 70 | 10.9.3 | Establish Golden Orbit Without User Bumps |  | 2eh | 2005-05-11 19:39 | 2005-05-11 21:39 | 69 | 2001-09-13 08:00 | 2001-09-13 11:00 | 3h | 0.14d | 0d | start no earlier than 2003-03-31 08:00 | Physics; Operators | 4h |
| 71 | 10.9.4 | Measure Response Matrix again |  | 1eh | 2005-05-11 21:39 | 2005-05-11 22:39 | 70 | 2001-09-13 11:00 | 2001-09-13 13:00 | 2h | 0.14d | 0d | start no earlier than 2003-03-31 08:00 | Physics; Operators | 2h |
| 72 | 10.10 | Test of HOM dampers 2 (different fill patterns and currents) |  | 8eh | 2005-05-11 22:39 | 2005-05-12 06:39 | 59, 66, 67 |  |  |  | 0.14d | 0d | start no earlier than 2003-03-31 08:00 | Kwiatkowski; Baptiste | 16h |
| 73 | 10.11 | Study transverse multibunch feedbacks with HOM dampers |  | 4eh | 2005-05-12 06:39 | 2005-05-12 10:39 | 72 | 2001-09-09 11:30 | 2001-09-09 13:30 | 2h | 0.14d | 0d | start no earlier than 2003-03-31 08:00 | Barry | 1.65h |
| 74 | 10.12 | Measurement of Beam Stability With Feedback Systems and HOM dampers at 400 Milliamps |  | 4eh | 2005-05-12 10:39 | 2005-05-12 14:39 | 73 |  |  |  | 0.14d | 0d | start no earlier than 2003-03-31 08:00 | Kwiatkowski; Barry; Stover | 12h |
| 75 | 10.13 | Fit Lattice Model |  | 4eh | 2005-05-11 22:39 | 2005-05-12 02:39 | 71 | 2001-09-13 13:00 | 2001-09-13 17:30 | 4h | 1.31d |  | start no earlier than 2003-03-31 08:00 | Steier | 4h |
| 76 | 10.14 | Generate Feed Forward Tables |  | 12eh | 2005-05-12 14:39 | 2005-05-13 02:39 | 74 | 2001-09-15 16:30 | 2001-09-16 09:30 | 8h | 0.14d | 0d | start no earlier than 2003-03-31 08:00 | Physics; Operators | 24h |
| 77 | 10.15 | Test Routine high current operation |  | 4eh | 2005-05-13 02:39 | 2005-05-13 06:39 | 76 |  |  |  | 0.14d |  | start no earlier than 2003-03-31 08:00 | Physics; Operators; Byrne [50%]; Byrd | 14h |
| 79 | 11 | HOM dampers decision point | milestone | 0d | 2005-05-12 06:39 | 2005-05-12 06:39 | 72 |  |  |  | 6.06d |  | start no earlier than 2003-04-25 08:00 | Byrd; Kwiatkowski; Robin; Steier |  |
| 81 | 12 | **Additional Beam Physics Studies** |  | 4.92d | 2005-05-13 06:39 | 2005-05-18 04:39 | 58 |  |  |  | 0.14d |  |  |  | 176h |
| 82 | 12.1 | Fast orbit feedback (new IP 2 boards) |  | 8eh | 2005-05-13 06:39 | 2005-05-13 14:39 |  | 2001-09-18 08:00 | 2001-09-18 16:00 | 8h | 0.14d | 0d | start no earlier than 2003-03-31 08:00 | Steier; Jacobson; Domning; Scarvie; Williams | 40h |
| 83 | 12.2 | Scan all small gap vacuum chambers for lifetime changes (especially IVID) |  | 8eh | 2005-05-13 14:39 | 2005-05-13 22:39 | 82 | 2001-09-16 09:30 | 2001-09-16 15:30 | 6h | 0.14d | 0d | start no earlier than 2003-03-31 08:00 | Physics; Operators | 16h |
| 84 | 12.3 | Additional tests with IVID (tune shift, orbit, dynamics, …) |  | 8eh | 2005-05-13 22:39 | 2005-05-14 06:39 | 83 |  |  |  | 0.14d | 0d |  | Steier; Wittmer; Portmann; Wan; Robin | 40h |
| 85 | 12.4 | Dynamics studies (gap vs. lifetime) |  | 12eh | 2005-05-14 06:39 | 2005-05-14 18:39 | 84 |  |  |  | 0.14d | 0d |  | Robin; Steier; Wan | 36h |
| 86 | 12.5 | New skew quadupole - local dispersion bump |  | 12eh | 2005-05-14 18:39 | 2005-05-15 06:39 | 85 |  |  |  | 0.14d | 0d |  | Wittmer; Steier; Robin | 36h |
| 87 | 12.6 | Additional Middle Layer Tests - will be used during whole startup |  | 12eh | 2005-05-15 06:39 | 2005-05-15 18:39 | 86 |  |  |  | 0.14d | 0d |  |  |  |
| 88 | 12.7 | Test digital feedorward for EPUs |  | 4eh | 2005-05-15 18:39 | 2005-05-15 22:39 | 87 |  |  |  | 0.14d | 0d |  |  |  |
| 89 | 12.8 | EPBI test # 3 for IVID |  | 4eh | 2005-05-15 22:39 | 2005-05-16 02:39 | 88 |  |  |  | 0.14d | 0d |  | Byrne; Nishimura | 8h |
| 90 | 12.9 | Test new IDBPMs |  | 2eh | 2005-05-16 02:39 | 2005-05-16 04:39 | 89 |  |  |  | 0.14d | 0d |  |  |  |
| 91 | 12.10 | Test new skew coil in sector 11 [11 1] |  | 2eh | 2005-05-16 04:39 | 2005-05-16 06:39 | 90 |  |  |  | 0.14d | 0d |  |  |  |
| 92 | 12.11 | Skew FF table for [11 1] |  | 12eh | 2005-05-16 06:39 | 2005-05-16 18:39 | 91 |  |  |  | 0.14d | 0d |  |  |  |
| 93 | 12.12 | New FF tables (sector 6,11, … ?) |  | 4eh | 2005-05-16 18:39 | 2005-05-16 22:39 | 92 |  |  |  | 0.14d | 0d |  |  |  |
| 94 | 12.13 | Move injection septa/straight further |  | 6eh | 2005-05-16 22:39 | 2005-05-17 04:39 | 93 |  |  |  | 0.14d | 0d |  |  |  |
| 95 | 12.14 | More coupling/dynamics studies |  | 8eh | 2005-05-17 04:39 | 2005-05-17 12:39 | 94 |  |  |  | 0.14d | 0d |  |  |  |
| 96 | 12.15 | Test beam bumps for users? |  | 4eh | 2005-05-17 12:39 | 2005-05-17 16:39 | 95 |  |  |  | 0.14d | 0d |  |  |  |
| 97 | 12.16 | Low current scrubbing/beam time for some users |  | 12eh | 2005-05-17 16:39 | 2005-05-18 04:39 | 96 |  |  |  | 0.14d |  |  |  |  |
| 99 | 13 | Key enable all beamlines (WITHOUT opening the shutter) |  | 3ed | 2005-05-12 08:00 | 2005-05-15 08:00 |  |  |  |  | 3d |  | start no earlier than 2005-05-12 08:00 | Hamamoto; Byrne [50%] | 108h |

| ID | WBS | Task | Duration | Start | Finish | Predecessors | Total slack | Free slack | Constraint | Resources | Work |
| --- | --- | --- | --- | --- | --- | --- | --- | --- | --- | --- | --- |
| 101 | 14 | **Operations tests with beamline scientists** | 3d | 2005-05-15 08:00 | 2005-05-18 08:00 | 58 | 0d |  |  |  | 216h |
| 102 | 14.1 | Get Beamlines online | 2eh | 2005-05-15 08:00 | 2005-05-15 10:00 |  | 0d |  | start no earlier than 2005-05-15 08:00 | Byrne; Hamamoto | 4h |
| 103 | 14.2 | Evaluate Overall Beam Stability/Quality with Beamlines | 2eh | 2005-05-15 10:00 | 2005-05-15 12:00 | 102 | 0d |  | start no earlier than 2003-03-31 08:00 | Byrne; Beamlines; Byrd; Steier | 8h |
| 104 | 14.3 | Absolute Orbit / bumps | 8eh | 2005-05-15 12:00 | 2005-05-15 20:00 | 103 | 0d |  | start no earlier than 2003-03-31 08:00 | Byrne; Duarte; Beamlines | 24h |
| 105 | 14.4 | Align (potentially frontends) | 14eh | 2005-05-15 20:00 | 2005-05-16 10:00 | 104 | 0d |  | start no earlier than 2003-03-31 08:00 | Byrne; Duarte; Beamlines | 42h |
| 106 | 14.5 | Reevaluate Beamlines | 6eh | 2005-05-16 10:00 | 2005-05-16 16:00 | 105 | 0d |  | start no earlier than 2003-03-31 08:00 | Byrne; Duarte; Beamlines | 18h |
| 107 | 14.6 | Fine Tune Beamline Alignment / Routine Operation | 40eh | 2005-05-16 16:00 | 2005-05-18 08:00 | 106 | 0d |  | start no earlier than 2003-03-31 08:00 | Byrne; Duarte; Beamlines | 120h |
| 109 | 15 | **Align beamlines as necessary (reduced because storage ring was not realigned)** | 37d | 2005-04-11 08:00 | 2005-05-18 08:00 |  | 0d |  |  |  | 2592h |
| 110 | 15.1 | Frontends/inside tunnel | 26ed | 2005-04-11 08:00 | 2005-05-07 08:00 |  | 2d | 0d | start no earlier than 2005-04-11 08:00 | Duarte; Byrne; Gavidia | 1872h |
| 111 | 15.2 | Outside tunnel | 9ed | 2005-05-07 08:00 | 2005-05-16 08:00 | 110 | 2d |  | start no earlier than 2003-04-21 08:00 | Duarte; Gavidia; Beamlines | 648h |
| 112 | 15.3 | Final optimization | 3ed | 2005-05-15 08:00 | 2005-05-18 08:00 |  | 0d |  | start no earlier than 2005-05-15 08:00 | Beamlines | 72h |
